# SERVICIO DE HABILITACIÓN DE ACCESOS Y PLATAFORMAS, Y MOVIMIENTO DE TIERRAS II PARTE - CUENCA HUAURA

Schedule from Primavera P6, 2023-03-10 to 2024-02-07, data date 2023-03-10.

## Calendars

- Dos turnos - 6x1 - 10 horas: Mon-Sat 01:00-06:00, 07:00-12:00, 13:00-18:00, 19:00-00:00; Sun off. Exceptions (off unless hours are given): 2023-04-06 to 2023-04-07, 2023-05-01, 2023-06-29, 2023-07-28 to 2023-07-29, 2023-08-30, 2023-11-01, 2023-12-08, 2023-12-25, 2024-01-01.

## Schedule

| ID | WBS | Activity | Type | Duration | Start | Finish | Predecessors | Total float | Free float |
| --- | --- | --- | --- | --- | --- | --- | --- | --- | --- |
|  | 1 | **Hitos** |  |  | 2023-03-10 | 2024-01-31 |  |  |  |
| A1000 |  | Suscripción del contrato | milestone | 0d | 2023-03-10 | 2023-03-10 |  | 0d |  |
| A1010 |  | Inicio de obra - Acceso al Sitio | milestone | 0d | 2023-04-01 | 2023-04-01 | A1000 FS+19d | 0d |  |
| A1020 |  | Inicio de Habilitación y mejoramiento de accesos | milestone | 0d | 2023-04-11 | 2023-04-11 | A1160 SS+3d | 0d |  |
| A1030 |  | Inicio de Movimiento de Tierras - Diques Paquete 2 | milestone | 0d | 2023-04-21 | 2023-04-21 | A1130 SS+6d | 0d |  |
| A1050 |  | Inicio de Movimiento de Tierras - Diques Paquete 3 | milestone | 0d | 2023-07-01 | 2023-07-01 | A1010 FS+74d | 6d | 0d |
| A1040 |  | Culminación de Diques Paquete 2 | milestone | 0d | 2023-10-26 | 2023-10-26 | A1180, A1220, A1230, A1240, A1260, A1300, A1320, A1330, A1355, A1360, A1370, A1380, A1390, A1420, A1440, A1450, A1515, A1520, A1530, A1540, A1550, A1580, A1600, A1610, A1675, A1680, A1690, A1700, A1710, A1720, A1730, A1725, A1740, A1770, A1760, A3520, A3540 | 79d |  |
| A1060 |  | Culminación de Diques Paquete 3 | milestone | 0d | 2024-01-31 | 2024-01-31 | A1805, A1810, A1820, A1830, A1840, A1850, A1880, A1900, A1910, A1945, A1950, A1960, A1970, A1980, A1990, A2020, A2040, A2050, A2105, A2120, A2130, A2140, A2150, A2180, A2200, A2210, A2265, A2280, A2290, A2300, A2310, A2340, A2360, A2370, A2425, A2440, A2450, A2460, A2470, A2500, A2520, A2530, A2585, A2600, A2610, A2620, A2630, A2660, A2680, A2690, A2745, A2760, A2770, A2780, A2790, A2820, A2840, A2850, A2905, A2920, A2930, A2940, A2950, A2980, A3000, A3010, A3065, A3080, A3090, A3100, A3110, A3140, A3160, A3170, A3225, A3240, A3250, A3260, A3270, A3300, A3320, A3330, A3385, A3400, A3410, A3420, A3430, A3460, A3480, A3490, A3530, A3550, A3800, A3810, A3780, A3550 FF, A3570, A3820, A3790, A3785, A3730, A3710, A3770 | 0d |  |
|  | 2 | **Obras Provisionales** |  |  | 2023-04-01 | 2024-02-07 |  |  |  |
| A1070 |  | Movilización |  | 26d | 2023-04-01 | 2023-05-05 | A1010 | 0d |  |
| A1080 |  | Mejoramiento y habilitación de caminos de acceso |  | 32d | 2023-04-11 | 2023-05-19 | A1020 | 0d |  |
| A1090 |  | Limpieza manual de material vegetal y de residuos |  | 32d | 2023-04-11 | 2023-05-19 | A1080 SS | 212d |  |
| A1120 |  | Habilitación de plataformas |  | 26d | 2023-04-14 | 2023-05-16 | A1130 SS | 215d |  |
| A1130 |  | Campamento Provisional de Obra |  | 26d | 2023-04-14 | 2023-05-16 | A1080 SS+3d | 0d |  |
| A1140 |  | Mantenimiento de caminos de acceso |  | 210d | 2023-05-19 | 2024-01-28 | A1080 | 2d |  |
| A1150 |  | Desmovilización |  | 6d | 2024-01-31 | 2024-02-07 | A1140, A1060, A1090, A1120, A1040 | 0d |  |
|  | 3 | **Topografía** |  |  | 2023-04-05 | 2023-05-09 |  |  |  |
| A1160 |  | Trazo y replanteo inicial |  | 26d | 2023-04-05 | 2023-05-09 | A1070 SS+3d | 0d |  |
|  | 4 | **Paquete 2** |  |  | 2023-04-21 | 2023-10-26 |  |  |  |
|  | 1 | **DE-PR-24-D** |  |  | 2023-04-21 | 2023-06-02 |  |  |  |
|  | 1 | **Excavaciones** |  |  | 2023-04-21 | 2023-05-12 |  |  |  |
| A1515 |  | Excavación - desbroce + cimentación + sobre excavación |  | 7d | 2023-04-21 | 2023-04-29 | A1030 | 0d |  |
| A1520 |  | Perfilado y conformación de plataforma de fundación |  | 3d | 2023-04-29 | 2023-05-04 | A1515 | 0d |  |
| A1530 |  | Excavación de uña |  | 7d | 2023-05-04 | 2023-05-12 | A1520 SS+3d | 0d |  |

| ID | WBS | Activity | Duration | Start | Finish | Predecessors | Total float | Free float |
| --- | --- | --- | --- | --- | --- | --- | --- | --- |
|  | 2 | **Cuerpo de Dique** |  | 2023-05-08 | 2023-05-19 |  |  |  |
| A1540 |  | Cuerpo del dique - material granular + material seleccionado | 7d | 2023-05-08 | 2023-05-16 | A1530 SS+3d | 0d |  |
| A1550 |  | Perfilado de Talud del dique | 4d | 2023-05-15 | 2023-05-19 | A1540 SS+6d | 0d |  |
|  | 3 | **Geotextil** |  | 2023-05-19 | 2023-05-21 |  |  |  |
| A1580 |  | Instalación de Geotextil | 2d | 2023-05-19 | 2023-05-21 | A1550 | 0d |  |
|  | 4 | **Colocación de Roca** |  | 2023-05-23 | 2023-06-02 |  |  |  |
| A1600 |  | Colocación de roca de uña | 7d | 2023-05-23 | 2023-05-31 | A1580 SS+3d | 0d |  |
| A1610 |  | Colocación de roca de talud | 6d | 2023-05-26 | 2023-06-02 | A1600 SS+3d | 8d | 1d |
|  | 2 | **DI-PR-25-I** |  | 2023-04-29 | 2023-06-06 |  |  |  |
|  | 1 | **Excavaciones** |  | 2023-04-29 | 2023-05-16 |  |  |  |
| A1675 |  | Excavación - desbroce + cimentación + sobre excavación | 2d | 2023-04-29 | 2023-05-03 | A1515 | 3d | 0d |
| A1680 |  | Perfilado y conformación de plataforma de fundación | 2d | 2023-05-04 | 2023-05-06 | A1520 | 6d | 3d |
| A1690 |  | Excavación de uña | 3d | 2023-05-12 | 2023-05-16 | A1530 | 1d | 0d |
|  | 2 | **Cuerpo de Dique** |  | 2023-05-16 | 2023-05-21 |  |  |  |
| A1700 |  | Cuerpo del dique - material granular + material seleccionado | 3d | 2023-05-16 | 2023-05-19 | A1690 SS+3d, A1540 | 1d | 0d |
| A1710 |  | Perfilado de Talud del dique | 2d | 2023-05-19 | 2023-05-21 | A1700, A1550 | 3d | 0d |
|  | 3 | **Geotextil** |  | 2023-05-22 | 2023-05-27 |  |  |  |
| A1740 |  | Instalación de Geotextil | 5d | 2023-05-22 | 2023-05-27 | A1580, A1710 | 3d | 2d |
|  | 4 | **Colocación de Roca** |  | 2023-05-31 | 2023-06-06 |  |  |  |
| A1760 |  | Colocación de roca de uña | 3d | 2023-05-31 | 2023-06-03 | A1740 SS+3d, A1600 | 0d |  |
| A1770 |  | Colocación de roca de talud | 2d | 2023-06-03 | 2023-06-06 | A1610, A1760 | 7d | 4d |
|  | 3 | **DI-PR-12-I** |  | 2023-04-21 | 2023-09-10 |  |  |  |
|  | 1 | **Dique Existente** |  | 2023-04-21 | 2023-06-04 |  |  |  |
| A3580 |  | Extracción y selección de rocas reutilizables | 37d | 2023-04-21 | 2023-06-04 | A1030 | 112d | 0d |
| A3590 |  | Remoción de dique existente | 37d | 2023-04-21 | 2023-06-04 | A3580 SS | 112d | 0d |

| ID | WBS | Activity | Duration | Start | Finish | Predecessors | Total float | Free float |
| --- | --- | --- | --- | --- | --- | --- | --- | --- |
|  | 2 | **Excavaciones** |  | 2023-05-03 | 2023-06-27 |  |  |  |
| A1180 |  | Excavación - desbroce + cimentación + sobre excavación | 42d | 2023-05-03 | 2023-06-21 | A1675 | 3d | 0d |
| A1220 |  | Perfilado y conformación de plataforma de fundación | 39d | 2023-05-10 | 2023-06-24 | A1180 SS+6d, A1680 | 3d | 2d |
| A1230 |  | Excavación de uña | 36d | 2023-05-16 | 2023-06-27 | A1220 SS+3d, A1690 | 1d | 0d |
|  | 3 | **Cuerpo de Dique** |  | 2023-05-19 | 2023-07-16 |  |  |  |
| A1240 |  | Cuerpo del dique - material granular + material seleccionado | 48d | 2023-05-19 | 2023-07-15 | A1230 SS+3d, A1700 | 1d | 0d |
| A1260 |  | Perfilado de Talud del dique | 43d | 2023-05-26 | 2023-07-16 | A1240 SS+6d, A1710 | 1d | 0d |
|  | 4 | **Geotextil** |  | 2023-05-30 | 2023-08-16 |  |  |  |
| A1300 |  | Instalación de Geotextil | 64d | 2023-05-30 | 2023-08-16 | A1260 SS+3d, A1740 | 1d | 0d |
|  | 5 | **Colocación de Roca** |  | 2023-06-03 | 2023-09-10 |  |  |  |
| A1320 |  | Colocación de roca de uña | 78d | 2023-06-03 | 2023-09-07 | A1300 SS+3d, A1760 | 0d |  |
| A1330 |  | Colocación de roca de talud | 75d | 2023-06-10 | 2023-09-10 | A1320 SS+6d, A1770 | 3d |  |
|  | 4 | **DI-PR-13-D** |  | 2023-06-05 | 2023-10-12 |  |  |  |
|  | 1 | **Dique Existente** |  | 2023-06-05 | 2023-06-29 |  |  |  |
| A3600 |  | Extracción y selección de rocas reutilizables | 21d | 2023-06-05 | 2023-06-29 | A3590 | 112d | 0d |
| A3610 |  | Remoción de dique existente | 21d | 2023-06-05 | 2023-06-29 | A3600 SS | 112d | 1d |
|  | 2 | **Excavaciones** |  | 2023-06-21 | 2023-07-09 |  |  |  |
| A1355 |  | Excavación - desbroce + cimentación + sobre excavación | 8d | 2023-06-21 | 2023-07-01 | A1180 | 29d | 0d |
| A1360 |  | Perfilado y conformación de plataforma de fundación | 8d | 2023-06-28 | 2023-07-08 | A1220, A1355 SS+6d | 29d | 0d |
| A1370 |  | Excavación de uña | 6d | 2023-07-03 | 2023-07-09 | A1230, A1360 SS+3d | 29d | 8d |
|  | 3 | **Cuerpo de Dique** |  | 2023-07-15 | 2023-08-08 |  |  |  |
| A1380 |  | Cuerpo del dique - material granular + material seleccionado | 17d | 2023-07-15 | 2023-08-06 | A1370 SS+3d, A1240 | 21d | 0d |
| A1390 |  | Perfilado de Talud del dique | 12d | 2023-07-22 | 2023-08-08 | A1380 SS+6d, A1260 | 31d | 5d |
|  | 4 | **Geotextil** |  | 2023-08-16 | 2023-08-29 |  |  |  |
| A1420 |  | Instalación de Geotextil | 11d | 2023-08-16 | 2023-08-29 | A1300, A1390 SS+3d | 15d | 0d |

| ID | WBS | Activity | Duration | Start | Finish | Predecessors | Total float | Free float |
| --- | --- | --- | --- | --- | --- | --- | --- | --- |
|  | 5 | **Colocación de Roca** |  | 2023-09-07 | 2023-10-12 |  |  |  |
| A1440 |  | Colocación de roca de uña | 17d | 2023-09-07 | 2023-09-27 | A1420 SS+3d, A1320 | 0d |  |
| A1450 |  | Colocación de roca de talud | 24d | 2023-09-14 | 2023-10-12 | A1330, A1440 SS+6d | 0d |  |
|  | 5 | **Rellenos Complementarios** |  | 2023-08-07 | 2023-10-26 |  |  |  |
| A1725 |  | Grava para drenaje | 29d | 2023-08-07 | 2023-09-10 | A1380 | 118d | 39d |
| A1720 |  | Relleno sin compactar sobre uña | 32d | 2023-09-12 | 2023-10-19 | A1450 FF+6d | 85d | 6d |
| A1730 |  | Relleno afirmado | 12d | 2023-10-12 | 2023-10-26 | A1450 | 79d | 0d |
|  | 5 | **Paquete 3** |  | 2023-07-01 | 2024-01-31 |  |  |  |
|  | 1 | **DI-PR-13-D-1** |  | 2023-07-01 | 2023-11-14 |  |  |  |
|  | 1 | **Dique Existente** |  | 2023-07-01 | 2023-08-06 |  |  |  |
| A3620 |  | Extracción y selección de rocas reutilizables | 29d | 2023-07-01 | 2023-08-06 | A1050, A3610 | 111d | 0d |
| A3630 |  | Remoción de dique existente | 29d | 2023-07-01 | 2023-08-06 | A3620 SS | 111d | 0d |
|  | 2 | **Excavaciones** |  | 2023-07-01 | 2023-07-26 |  |  |  |
| A1805 |  | Excavación - desbroce + cimentación + sobre excavación | 18d | 2023-07-01 | 2023-07-22 | A1050, A1355 | 41d | 0d |
| A1810 |  | Remoción Dique Existente | 18d | 2023-07-01 | 2023-07-22 | A1805 SS | 156d | 0d |
| A1820 |  | Perfilado y conformación de plataforma de fundación | 17d | 2023-07-05 | 2023-07-25 | A1805 SS+3d | 41d | 0d |
| A1830 |  | Excavación de uña | 15d | 2023-07-08 | 2023-07-26 | A1820 SS+3d | 41d | 3d |
|  | 3 | **Rellenos** |  | 2023-08-07 | 2023-09-10 |  |  |  |
| A1840 |  | Cuerpo del dique - material granular + material seleccionado | 28d | 2023-08-07 | 2023-09-09 | A1830 SS+3d, A1380 | 21d | 0d |
| A1850 |  | Perfilado de Talud del dique | 23d | 2023-08-14 | 2023-09-10 | A1840 SS+6d, A1390 | 27d | 1d |
|  | 4 | **Geotextil** |  | 2023-08-29 | 2023-09-27 |  |  |  |
| A1880 |  | Instalación de Geotextil | 24d | 2023-08-29 | 2023-09-27 | A1850 SS+3d, A1420 | 17d | 0d |
|  | 5 | **Colocación de Roca** |  | 2023-09-27 | 2023-11-14 |  |  |  |
| A1900 |  | Colocación de roca de uña | 23d | 2023-09-27 | 2023-10-24 | A1880 SS+3d, A1440 | 7d | 0d |
| A1910 |  | Colocación de roca de talud | 27d | 2023-10-12 | 2023-11-14 | A1900 SS+6d, A1450 | 0d |  |

| ID | WBS | Activity | Duration | Start | Finish | Predecessors | Total float | Free float |
| --- | --- | --- | --- | --- | --- | --- | --- | --- |
|  | 2 | **DI-PR-13-D-2** |  | 2023-07-22 | 2023-11-16 |  |  |  |
|  | 1 | **Dique Existente** |  | 2023-08-07 | 2023-08-09 |  |  |  |
| A3640 |  | Extracción y selección de rocas reutilizables | 2d | 2023-08-07 | 2023-08-09 | A3630 | 111d | 0d |
| A3650 |  | Remoción de dique existente | 2d | 2023-08-07 | 2023-08-09 | A3640 SS | 111d | 0d |
|  | 2 | **Excavaciones** |  | 2023-07-22 | 2023-08-03 |  |  |  |
| A1945 |  | Excavación - desbroce + cimentación + sobre excavación | 2d | 2023-07-22 | 2023-07-25 | A1805 | 49d | 0d |
| A1950 |  | Remoción Dique Existente | 2d | 2023-07-22 | 2023-07-25 | A1945 SS, A1810 | 156d |  |
| A1960 |  | Perfilado y conformación de plataforma de fundación | 2d | 2023-07-26 | 2023-07-28 | A1945 SS+3d, A1820 | 99d | 0d |
| A1970 |  | Excavación de uña | 2d | 2023-08-01 | 2023-08-03 | A1945 SS+6d, A1830 | 50d | 0d |
|  | 3 | **Rellenos** |  | 2023-09-09 | 2023-09-14 |  |  |  |
| A1980 |  | Cuerpo del dique - material granular + material seleccionado | 2d | 2023-09-09 | 2023-09-12 | A1970 SS+3d, A1840 | 21d | 0d |
| A1990 |  | Perfilado de Talud del dique | 2d | 2023-09-12 | 2023-09-14 | A1980, A1850 | 27d | 5d |
|  | 4 | **Geotextil** |  | 2023-09-27 | 2023-09-29 |  |  |  |
| A2020 |  | Instalación de Geotextil | 2d | 2023-09-27 | 2023-09-29 | A1990 SS+3d, A1880 | 17d | 0d |
|  | 5 | **Colocación de Roca** |  | 2023-10-24 | 2023-11-16 |  |  |  |
| A2040 |  | Colocación de roca de uña | 2d | 2023-10-24 | 2023-10-26 | A2020 SS+3d, A1900 | 8d | 0d |
| A2050 |  | Colocación de roca de talud | 2d | 2023-11-14 | 2023-11-16 | A2040, A1910 | 0d |  |
|  | 3 | **DI-PR-13-D-3** |  | 2023-07-25 | 2023-11-18 |  |  |  |
|  | 1 | **Dique Existente** |  | 2023-08-09 | 2023-08-18 |  |  |  |
| A3660 |  | Extracción y selección de rocas reutilizables | 8d | 2023-08-09 | 2023-08-18 | A3650 | 111d | 0d |
| A3670 |  | Remoción de dique existente | 8d | 2023-08-09 | 2023-08-18 | A3660 SS | 111d | 0d |
|  | 2 | **Excavaciones** |  | 2023-07-25 | 2023-08-10 |  |  |  |
| A2105 |  | Excavación - desbroce + cimentación + sobre excavación | 7d | 2023-07-25 | 2023-08-04 | A1945 | 49d | 0d |
| A2120 |  | Perfilado y conformación de plataforma de fundación | 5d | 2023-07-31 | 2023-08-05 | A2105 SS+3d, A1960 | 99d | 2d |
| A2130 |  | Excavación de uña | 6d | 2023-08-03 | 2023-08-10 | A2105 SS+6d, A1970 | 50d | 1d |

| ID | WBS | Activity | Duration | Start | Finish | Predecessors | Total float | Free float |
| --- | --- | --- | --- | --- | --- | --- | --- | --- |
|  | 3 | **Rellenos** |  | 2023-09-12 | 2023-09-22 |  |  |  |
| A2140 |  | Cuerpo del dique - material granular + material seleccionado | 7d | 2023-09-12 | 2023-09-20 | A2130 SS+3d, A1980 | 21d | 0d |
| A2150 |  | Perfilado de Talud del dique | 2d | 2023-09-20 | 2023-09-22 | A2140, A1990 | 22d | 3d |
|  | 4 | **Geotextil** |  | 2023-09-29 | 2023-10-06 |  |  |  |
| A2180 |  | Instalación de Geotextil | 6d | 2023-09-29 | 2023-10-06 | A2020, A2150 SS+3d | 17d | 0d |
|  | 5 | **Colocación de Roca** |  | 2023-10-26 | 2023-11-18 |  |  |  |
| A2200 |  | Colocación de roca de uña | 3d | 2023-10-26 | 2023-10-29 | A2180 SS+3d, A2040 | 8d | 0d |
| A2210 |  | Colocación de roca de talud | 2d | 2023-11-16 | 2023-11-18 | A2050 | 0d |  |
|  | 4 | **DI-PR-16-D** |  | 2023-08-04 | 2023-11-28 |  |  |  |
|  | 1 | **Dique Existente** |  | 2023-08-18 | 2023-08-27 |  |  |  |
| A3680 |  | Extracción y selección de rocas reutilizables | 8d | 2023-08-18 | 2023-08-27 | A3670 | 111d | 0d |
| A3690 |  | Remoción de dique existente | 8d | 2023-08-18 | 2023-08-27 | A3680 SS | 111d | 0d |
|  | 2 | **Excavaciones** |  | 2023-08-04 | 2023-08-19 |  |  |  |
| A2265 |  | Excavación - desbroce + cimentación + sobre excavación | 7d | 2023-08-04 | 2023-08-12 | A2105 | 49d | 0d |
| A2280 |  | Perfilado y conformación de plataforma de fundación | 6d | 2023-08-08 | 2023-08-15 | A2265 SS+3d, A2120 | 97d | 1d |
| A2290 |  | Excavación de uña | 7d | 2023-08-11 | 2023-08-19 | A2265 SS+6d, A2130 | 49d | 0d |
|  | 3 | **Rellenos** |  | 2023-09-20 | 2023-09-28 |  |  |  |
| A2300 |  | Cuerpo del dique - material granular + material seleccionado | 5d | 2023-09-20 | 2023-09-26 | A2290 SS+3d, A2140 | 21d | 0d |
| A2310 |  | Perfilado de Talud del dique | 2d | 2023-09-26 | 2023-09-28 | A2300, A2150 | 23d | 4d |
|  | 4 | **Geotextil** |  | 2023-10-06 | 2023-10-15 |  |  |  |
| A2340 |  | Instalación de Geotextil | 8d | 2023-10-06 | 2023-10-15 | A2180, A2310 SS+3d | 17d | 0d |
|  | 5 | **Colocación de Roca** |  | 2023-10-30 | 2023-11-28 |  |  |  |
| A2360 |  | Colocación de roca de uña | 7d | 2023-10-30 | 2023-11-08 | A2340 SS+3d, A2200 | 8d | 0d |
| A2370 |  | Colocación de roca de talud | 8d | 2023-11-18 | 2023-11-28 | A2210, A2360 SS+6d | 0d |  |

| ID | WBS | Activity | Duration | Start | Finish | Predecessors | Total float | Free float |
| --- | --- | --- | --- | --- | --- | --- | --- | --- |
|  | 5 | **DI-PR-17-D** |  | 2023-08-12 | 2023-12-05 |  |  |  |
|  | 1 | **Dique Existente** |  | 2023-08-28 | 2023-09-19 |  |  |  |
| A3700 |  | Extracción y selección de rocas reutilizables | 18d | 2023-08-28 | 2023-09-19 | A3690 | 111d | 0d |
| A3710 |  | Remoción de dique existente | 18d | 2023-08-28 | 2023-09-19 | A3700 SS | 111d |  |
|  | 2 | **Excavaciones** |  | 2023-08-12 | 2023-08-29 |  |  |  |
| A2425 |  | Excavación - desbroce + cimentación + sobre excavación | 6d | 2023-08-12 | 2023-08-19 | A2265 | 49d | 0d |
| A2440 |  | Perfilado y conformación de plataforma de fundación | 6d | 2023-08-16 | 2023-08-23 | A2425 SS+3d, A2280 | 96d | 0d |
| A2450 |  | Excavación de uña | 8d | 2023-08-19 | 2023-08-29 | A2425 SS+6d, A2290 | 49d | 0d |
|  | 3 | **Rellenos** |  | 2023-09-26 | 2023-10-13 |  |  |  |
| A2460 |  | Cuerpo del dique - material granular + material seleccionado | 12d | 2023-09-26 | 2023-10-10 | A2450 SS+3d, A2300 | 21d | 0d |
| A2470 |  | Perfilado de Talud del dique | 9d | 2023-10-03 | 2023-10-13 | A2460 SS+6d, A2310 | 25d | 8d |
|  | 4 | **Geotextil** |  | 2023-10-16 | 2023-11-01 |  |  |  |
| A2500 |  | Instalación de Geotextil | 14d | 2023-10-16 | 2023-11-01 | A2340, A2470 SS+3d | 17d | 0d |
|  | 5 | **Colocación de Roca** |  | 2023-11-08 | 2023-12-05 |  |  |  |
| A2520 |  | Colocación de roca de uña | 7d | 2023-11-08 | 2023-11-16 | A2500 SS+3d, A2360 | 8d | 0d |
| A2530 |  | Colocación de roca de talud | 6d | 2023-11-28 | 2023-12-05 | A2370, A2520 SS+6d | 0d |  |
|  | 6 | **DI-PR-18-D-1** |  | 2023-08-19 | 2023-12-22 |  |  |  |
|  | 1 | **Excavaciones** |  | 2023-08-19 | 2023-09-07 |  |  |  |
| A2585 |  | Excavación - desbroce + cimentación + sobre excavación | 7d | 2023-08-19 | 2023-08-27 | A2425 | 55d | 0d |
| A2600 |  | Perfilado y conformación de plataforma de fundación | 5d | 2023-08-23 | 2023-08-29 | A2585 SS+3d, A2440 | 96d | 2d |
| A2610 |  | Excavación de uña | 7d | 2023-08-29 | 2023-09-07 | A2585 SS+6d, A2450 | 53d | 0d |
|  | 2 | **Rellenos** |  | 2023-10-10 | 2023-10-26 |  |  |  |
| A2620 |  | Cuerpo del dique - material granular + material seleccionado | 3d | 2023-10-10 | 2023-10-13 | A2610 SS+3d, A2460 | 21d | 0d |
| A2630 |  | Perfilado de Talud del dique | 2d | 2023-10-24 | 2023-10-26 | A2620 SS+12d, A2470 | 21d | 0d |

| ID | WBS | Activity | Duration | Start | Finish | Predecessors | Total float | Free float |
| --- | --- | --- | --- | --- | --- | --- | --- | --- |
|  | 3 | **Geotextil** |  | 2023-11-02 | 2023-11-09 |  |  |  |
| A2660 |  | Instalación de Geotextil | 6d | 2023-11-02 | 2023-11-09 | A2500, A2630 SS+3d | 17d | 0d |
|  | 4 | **Colocación de Roca** |  | 2023-11-16 | 2023-12-19 |  |  |  |
| A2680 |  | Colocación de roca de uña | 8d | 2023-11-16 | 2023-11-25 | A2660 SS+3d, A2520 | 8d | 0d |
| A2690 |  | Colocación de roca de talud | 11d | 2023-12-05 | 2023-12-19 | A2530, A2680 | 0d |  |
|  | 5 | **Protección con Gaviones** |  | 2023-11-09 | 2023-12-22 |  |  |  |
| A3720 |  | Protección de Talud con Colchón reno | 28d | 2023-11-09 | 2023-12-13 | A2660 | 32d | 0d |
| A3730 |  | Gavión de 1m x 1m | 8d | 2023-12-13 | 2023-12-22 | A3720 | 32d |  |
|  | 7 | **DI-PR-18-D-2** |  | 2023-08-28 | 2024-01-10 |  |  |  |
|  | 1 | **Excavaciones** |  | 2023-08-28 | 2023-09-22 |  |  |  |
| A2745 |  | Excavación - desbroce + cimentación + sobre excavación | 14d | 2023-08-28 | 2023-09-14 | A2585 | 67d | 0d |
| A2760 |  | Perfilado y conformación de plataforma de fundación | 12d | 2023-09-01 | 2023-09-15 | A2745 SS+3d, A2600 | 94d | 2d |
| A2770 |  | Excavación de uña | 13d | 2023-09-07 | 2023-09-22 | A2745 SS+6d, A2610 | 65d | 0d |
|  | 2 | **Rellenos** |  | 2023-10-13 | 2023-11-09 |  |  |  |
| A2780 |  | Cuerpo del dique - material granular + material seleccionado | 13d | 2023-10-13 | 2023-10-28 | A2770 SS+3d, A2620 | 37d | 0d |
| A2790 |  | Perfilado de Talud del dique | 11d | 2023-10-26 | 2023-11-09 | A2780 SS+6d, A2630 | 32d | 0d |
|  | 3 | **Geotextil** |  | 2023-11-09 | 2023-11-22 |  |  |  |
| A2820 |  | Instalación de Geotextil | 11d | 2023-11-09 | 2023-11-22 | A2790 SS+3d, A2660 | 24d | 0d |
|  | 4 | **Colocación de Roca** |  | 2023-11-25 | 2024-01-10 |  |  |  |
| A2840 |  | Colocación de roca de uña | 17d | 2023-11-25 | 2023-12-16 | A2820 SS+3d, A2680 | 13d | 0d |
| A2850 |  | Colocación de roca de talud | 17d | 2023-12-19 | 2024-01-10 | A2840 SS+6d, A2690 | 0d |  |
|  | 8 | **DI-PR-19A-D-1** |  | 2023-09-14 | 2024-01-30 |  |  |  |
|  | 1 | **Excavaciones** |  | 2023-09-14 | 2023-10-15 |  |  |  |
| A2905 |  | Excavación - desbroce + cimentación + sobre excavación | 21d | 2023-09-14 | 2023-10-08 | A2745 | 70d | 0d |
| A2920 |  | Perfilado y conformación de plataforma de fundación | 20d | 2023-09-18 | 2023-10-11 | A2905 SS+3d, A2760 | 92d |  |
| A2930 |  | Excavación de uña | 20d | 2023-09-22 | 2023-10-15 | A2905 SS+6d, A2770 | 69d | 28d |

| ID | WBS | Activity | Duration | Start | Finish | Predecessors | Total float | Free float |
| --- | --- | --- | --- | --- | --- | --- | --- | --- |
|  | 2 | **Rellenos** |  | 2023-10-28 | 2023-11-16 |  |  |  |
| A2940 |  | Cuerpo del dique - material granular + material seleccionado | 12d | 2023-10-28 | 2023-11-12 | A2930 SS+3d, A2780 | 41d | 3d |
| A2950 |  | Perfilado de Talud del dique | 6d | 2023-11-09 | 2023-11-16 | A2940 SS+6d, A2790 | 38d | 8d |
|  | 3 | **Geotextil** |  | 2023-11-22 | 2023-12-15 |  |  |  |
| A2980 |  | Instalación de Geotextil | 19d | 2023-11-22 | 2023-12-15 | A2820, A2950 SS+3d | 30d | 17d |
|  | 4 | **Colocación de Roca** |  | 2023-12-16 | 2024-01-30 |  |  |  |
| A3000 |  | Colocación de roca de uña | 18d | 2023-12-16 | 2024-01-09 | A2980 SS+3d, A2840 | 13d | 0d |
| A3010 |  | Colocación de roca de talud | 17d | 2024-01-10 | 2024-01-30 | A2850, A3000 SS+6d | 0d |  |
|  | 9 | **DI-PR-19A-D-2** |  | 2023-07-01 | 2023-10-13 |  |  |  |
|  | 1 | **Dique Existente** |  | 2023-07-01 | 2023-07-27 |  |  |  |
| A3740 |  | Extracción y selección de rocas reutilizables | 22d | 2023-07-01 | 2023-07-27 | A1050 | 116d | 0d |
| A3750 |  | Remoción de dique existente | 22d | 2023-07-01 | 2023-07-27 | A3740 SS | 116d | 0d |
|  | 2 | **Excavaciones** |  | 2023-07-01 | 2023-09-20 |  |  |  |
| A3065 |  | Excavación - desbroce + cimentación + sobre excavación | 61d | 2023-07-01 | 2023-09-14 | A1050 | 6d | 0d |
| A3080 |  | Perfilado y conformación de plataforma de fundación | 61d | 2023-07-05 | 2023-09-17 | A3065 SS+3d | 18d | 0d |
| A3090 |  | Excavación de uña | 60d | 2023-07-08 | 2023-09-20 | A3065 SS+6d | 7d | 0d |
|  | 3 | **Rellenos** |  | 2023-07-12 | 2023-09-24 |  |  |  |
| A3100 |  | Cuerpo del dique - material granular + material seleccionado | 60d | 2023-07-12 | 2023-09-23 | A3090 SS+3d | 7d | 0d |
| A3110 |  | Perfilado de Talud del dique | 55d | 2023-07-19 | 2023-09-24 | A3100 SS+6d | 9d | 0d |
|  | 4 | **Geotextil** |  | 2023-07-22 | 2023-09-27 |  |  |  |
| A3140 |  | Instalación de Geotextil | 54d | 2023-07-22 | 2023-09-27 | A3110 SS+3d | 9d | 0d |
|  | 5 | **Colocación de Roca** |  | 2023-07-31 | 2023-10-13 |  |  |  |
| A3160 |  | Colocación de roca de uña | 52d | 2023-07-31 | 2023-09-30 | A3140 FF+3d | 9d | 0d |
| A3170 |  | Colocación de roca de talud | 51d | 2023-08-14 | 2023-10-13 | A3160 SS+12d | 9d | 3d |

| ID | WBS | Activity | Duration | Start | Finish | Predecessors | Total float | Free float |
| --- | --- | --- | --- | --- | --- | --- | --- | --- |
|  | 10 | **DI-PR-19A-D-3** |  | 2023-07-27 | 2023-12-05 |  |  |  |
|  | 1 | **Dique Existente** |  | 2023-07-27 | 2023-09-13 |  |  |  |
| A3760 |  | Extracción y selección de rocas reutilizables | 38d | 2023-07-27 | 2023-09-13 | A3750 | 116d | 0d |
| A3770 |  | Remoción de dique existente | 38d | 2023-07-27 | 2023-09-13 | A3760 SS | 116d |  |
|  | 2 | **Excavaciones** |  | 2023-09-14 | 2023-10-29 |  |  |  |
| A3225 |  | Excavación - desbroce + cimentación + sobre excavación | 33d | 2023-09-14 | 2023-10-22 | A3065 | 6d | 0d |
| A3240 |  | Perfilado y conformación de plataforma de fundación | 33d | 2023-09-18 | 2023-10-26 | A3225 SS+3d, A3080 | 18d | 0d |
| A3250 |  | Excavación de uña | 33d | 2023-09-21 | 2023-10-29 | A3225 SS+6d, A3090 | 6d | 0d |
|  | 3 | **Rellenos** |  | 2023-09-25 | 2023-10-27 |  |  |  |
| A3260 |  | Cuerpo del dique - material granular + material seleccionado | 27d | 2023-09-25 | 2023-10-26 | A3250 SS+3d, A3100 | 6d | 0d |
| A3270 |  | Perfilado de Talud del dique | 22d | 2023-10-02 | 2023-10-27 | A3260 SS+6d, A3110 | 6d | 0d |
|  | 4 | **Geotextil** |  | 2023-10-05 | 2023-11-16 |  |  |  |
| A3300 |  | Instalación de Geotextil | 35d | 2023-10-05 | 2023-11-16 | A3140, A3270 SS+3d | 6d | 0d |
|  | 5 | **Colocación de Roca** |  | 2023-10-10 | 2023-12-05 |  |  |  |
| A3320 |  | Colocación de roca de uña | 34d | 2023-10-10 | 2023-11-19 | A3300 FF+3d, A3160 | 6d | 0d |
| A3330 |  | Colocación de roca de talud | 41d | 2023-10-17 | 2023-12-05 | A3170, A3320 SS+6d | 6d | 0d |
|  | 11 | **DI-PR-19B-D** |  | 2023-10-23 | 2024-01-23 |  |  |  |
|  | 1 | **Excavaciones** |  | 2023-10-23 | 2023-11-26 |  |  |  |
| A3385 |  | Excavación - desbroce + cimentación + sobre excavación | 24d | 2023-10-23 | 2023-11-21 | A3225 | 19d | 1d |
| A3400 |  | Perfilado y conformación de plataforma de fundación | 24d | 2023-10-26 | 2023-11-24 | A3385 SS+2d, A3240 | 18d | 1d |
| A3410 |  | Excavación de uña | 23d | 2023-10-30 | 2023-11-26 | A3400 SS+2d, A3250 | 17d | 0d |
|  | 2 | **Rellenos** |  | 2023-11-02 | 2023-11-28 |  |  |  |
| A3420 |  | Cuerpo del dique - material granular + material seleccionado | 21d | 2023-11-02 | 2023-11-26 | A3410 SS+2d, A3260 | 17d | 0d |
| A3430 |  | Perfilado de Talud del dique | 16d | 2023-11-09 | 2023-11-28 | A3420 SS+6d, A3270 | 17d | 3d |

| ID | WBS | Activity | Duration | Start | Finish | Predecessors | Total float | Free float |
| --- | --- | --- | --- | --- | --- | --- | --- | --- |
|  | 3 | **Geotextil** |  | 2023-11-16 | 2023-12-19 |  |  |  |
| A3460 |  | Instalación de Geotextil | 27d | 2023-11-16 | 2023-12-19 | A3430 SS+3d, A3300 | 14d | 1d |
|  | 4 | **Colocación de Roca** |  | 2023-11-20 | 2024-01-23 |  |  |  |
| A3480 |  | Colocación de roca de uña | 25d | 2023-11-20 | 2023-12-20 | A3460 SS+2d, A3320 | 13d | 7d |
| A3490 |  | Colocación de roca de talud | 39d | 2023-12-05 | 2024-01-23 | A3480 SS+6d, A3330 | 6d |  |
|  | 12 | **Rellenos Complementarios** |  | 2023-10-21 | 2024-01-31 |  |  |  |
| A3780 |  | Relleno sin compactar sobre uña - Periodo 1 | 49d | 2023-10-21 | 2023-12-20 | A2690 FF+1d | 34d |  |
| A3790 |  | Grava para drenaje | 4d | 2023-11-27 | 2023-12-01 | A3420 | 49d |  |
| A3800 |  | Relleno afirmado - Periodo 1 | 16d | 2023-11-30 | 2023-12-20 | A2690 FF+1d | 34d |  |
| A3785 |  | Relleno sin compactar sobre uña - Periodo 2 | 20d | 2023-12-21 | 2024-01-16 | A3000 FF+6d, A3480 FF+6d | 13d |  |
| A3810 |  | Relleno afirmado - Periodo 2 | 8d | 2024-01-22 | 2024-01-31 | A3490 FF+1d, A3010 FF+1d | 0d |  |
|  | 6 | **Obras Civiles** |  | 2023-04-21 | 2024-01-07 |  |  |  |
|  | 1 | **Paquete 2** |  | 2023-04-21 | 2023-11-03 |  |  |  |
| A3520 |  | Obras Civiles - Paquete 02 (11 estructuras) | 132d | 2023-04-21 | 2023-09-28 | A1030 | 43d | 0d |
| A3560 |  | Interferencias - diques paquete 02 | 30d | 2023-09-28 | 2023-11-03 | A3520 | 43d | 0d |
|  | 2 | **Paquete 3** |  | 2023-07-01 | 2024-01-07 |  |  |  |
| A3530 |  | Obras Civiles - Paquete 03 (13 Estructuras) | 156d | 2023-07-01 | 2024-01-07 | A1050 | 20d |  |
| A3570 |  | Interferencias - diques paquete 03 | 30d | 2023-11-03 | 2023-12-08 | A3560 | 43d |  |
|  | 7 | **Accesos** |  | 2023-08-09 | 2024-01-27 |  |  |  |
| A3540 |  | Accesos - Paquete 02 Frente 2 (04 Losas) | 48d | 2023-08-09 | 2023-10-05 | A3520 FF+6d | 97d | 18d |
| A3550 |  | Accesos - Paquete 03 Frente 2 (03 Losas) | 36d | 2023-11-13 | 2023-12-27 | A2690 FF+6d | 29d |  |
| A3820 |  | Accesos - Paquete 03 Frente 2 (01 Losa) | 12d | 2024-01-13 | 2024-01-27 | A3010 SS+3d | 3d |  |
